# A1-LACRAMARCA

Schedule from Primavera P6, 2023-11-30 to 2024-06-25, data date 2023-11-29.

## Calendars

- LACRAMARCA EFECTIVOS: Mon-Sat 08:00-16:30; Sun off. Exceptions (off unless hours are given): 2023-12-08 to 2023-12-09, 2023-12-25, 2024-01-01, 2024-03-28 to 2024-03-29, 2024-04-06 08:00-16:00, 2024-05-01.
- DÍAS CALENDARIOS: Mon-Sun 08:00-16:00.

## Resources

| Resource | Group | Notes |
| --- | --- | --- |
| Camión grua | labor | ï»¿ |
| CAPATAZ | labor | ï»¿ |
| OPERARIO | labor | ï»¿ |
| PEON | labor | ï»¿ |
| Camión Cisterna 4x2 400 HP Agua (5000 gal) | labor | ï»¿ |
| CUADRADOR/VIGÍA | labor | ï»¿ |
| Motoniveladora 185 HP | labor | ï»¿ |
| Retroexcavador 58 HP | labor | ï»¿ |
| Rodillo Vib. Liso Autopropulsado 135 HP 12 TM | labor | ï»¿ |
| Camión baranda 3 TON | labor | ï»¿ |
| Camión Plataforma 4x2 122 HP | labor | ï»¿ |
| Camión Volquete (15 m3) | labor | ï»¿ |
| Cargador Frontal 195 HP | labor | ï»¿ |
| CARGADOR SOBRE LLANTAS DE 200-250 HP | labor | ï»¿ |
| Excavadora Sobre Oruga 260 HP | labor | ï»¿ |
| Tractor S/Orugas (D6T) - 180 HP | labor | ï»¿ |
| Camión Volquete Roquero (15 m3) | labor | ï»¿ |
| OFICIAL | labor | ï»¿ |
| Excavadora + Martillo hidraúlico | labor | ï»¿ |
| Excavadora Sobre Oruga 320 | labor | ï»¿ |
| AYUDANTE DE NIVELADOR | labor | ï»¿ |
| AYUDANTE DE TOPOGRAFO | labor | ï»¿ |
| TOPOGRAFO | labor | ï»¿ |
| OP. NIVELADOR | labor | ï»¿ |

## Schedule

| ID | WBS | Activity | Type | Duration | Start | Finish | Predecessors | Total float | Free float | Calendar | Resources |
| --- | --- | --- | --- | --- | --- | --- | --- | --- | --- | --- | --- |
|  | 1 | **HITOS** |  |  | 2023-11-30 | 2023-12-03 |  |  |  |  |  |
| A1010 |  | BUENA PRO | milestone | 0d | 2023-11-30 | 2023-11-30 |  | -0.03d | 0d | DÍAS CALENDARIOS |  |
| A1020 |  | KICK OF MEETING (KMO) | milestone | 0d | 2023-12-03 | 2023-12-03 | A1010 SS+3d | -0.03d | 0d | DÍAS CALENDARIOS |  |
|  | 2 | **INICIO DEL PLAZO CONTRACTUAL - FIN DEL PLAZO CONTRACTUAL** |  |  | 2023-12-18 | 2024-06-25 |  |  |  |  |  |
| A1030 |  | INICIO DEL PLAZO CONTRACTUAL - ACCESO AL SITIO | milestone | 0d | 2023-12-18 | 2023-12-18 | A1020 SS+15d | -0.03d | 0d | DÍAS CALENDARIOS |  |
| A1040 |  | INICIO DE EXCAVACIÓN | milestone | 0d | 2024-01-06 | 2024-01-06 | A1030 SS+19.5d | -0.03d | 0d | DÍAS CALENDARIOS |  |
| A1054 |  | INICIO DE DIQUE MARGEN IZQUIERDA | milestone | 0d | 2024-01-06 | 2024-01-06 | A1040 SS | 0.28d | 0d | DÍAS CALENDARIOS |  |
| A1055 |  | INICIO DE DIQUE MARGEN DERECHA | milestone | 0d | 2024-01-16 | 2024-01-16 | A1040 SS+10d | 0.9d | 0d | DÍAS CALENDARIOS |  |
| A1050 |  | INICIO DE RELLENO DE DIQUE | milestone | 0d | 2024-01-29 | 2024-01-29 | A1040 SS+23d | 5.33d | 0d | DÍAS CALENDARIOS |  |
| A1057 |  | FIN DE DIQUE MARGEN IZQUIERDA | milestone | 0d | 2024-06-01 | 2024-06-01 | A1054 SF+147d | 3.84d | 0.88d | DÍAS CALENDARIOS |  |
| A1058 |  | FIN DE DIQUE MARGEN DERECHA | milestone | 0d | 2024-06-21 | 2024-06-21 | A1055 SF+157d | 0.9d |  | DÍAS CALENDARIOS |  |
| A1060 |  | FIN DE PLAZO CONTRACTUAL-CULMINACIÓN DE OBRA | milestone | 0d | 2024-06-25 | 2024-06-25 | 01.10.03 FF | 0d |  | DÍAS CALENDARIOS |  |
|  | 3 | **CONSTRUCCIÓN SUB PROYECTO A1-RÍO LACRAMARCA** |  |  | 2023-12-18 | 2024-06-24 |  |  |  |  |  |
|  | 1 | **SUBPROYECTO A1 (OPCIÓN A)** |  |  | 2023-12-18 | 2024-06-20 |  |  |  |  |  |
|  | 1 | **DEFENSAS RIBEREÑAS** |  |  | 2023-12-18 | 2024-06-20 |  |  |  |  |  |
|  | 1 | **OBRAS PRELIMINARES** |  |  | 2024-01-06 | 2024-06-17 |  |  |  |  |  |
| 1.01.01 |  | CARTEL DE IDENTIFICACIÓN OBRA 4.80 x 3.60 m. |  | 0.53d | 2024-01-06 | 2024-01-06 | 1.01.02 SS | 6d | 0.02d |  | CAPATAZ [0.1 h]; OPERARIO [1 h]; PEON [1 h] |
| 1.01.02 |  | INSTALACIONES PROVISIONALES PARA LA OBRA |  | 3.5d | 2024-01-06 | 2024-01-10 | 01.02.01 SS+15.35d | 6d | 0d |  | Camión grua [60 h]; CAPATAZ [30 h]; OPERARIO [480 h]; PEON [960 h] |
| 1.01.03 |  | MANTENIMIENTO DE TRÁNSITO Y SEGURIDAD VIAL |  | 136.5d | 2024-01-06 | 2024-06-17 | 01.02.01 SS+15.35d | 6.03d | 6.05d |  | Camión Cisterna 4x2 400 HP Agua (5000 gal) [468 h]; CAPATAZ [234 h]; CUADRADOR/VIGÍA [468 h]; Motoniveladora 185 HP [468 h]; Retroexcavador 58 HP [468 h]; Rodillo Vib. Liso Autopropulsado 135 HP 12 TM [468 h] |
|  | 2 | **TRABAJOS PRELIMINARES** |  |  | 2023-12-18 | 2024-06-17 |  |  |  |  |  |
| 01.02.01 |  | MOVILIZACION Y DESMOVILIZACIÓN DE EQUIPOS |  | 13.76d | 2023-12-18 | 2024-01-04 | A1030 SS-0.4d | 0.41d | 0d |  | Camión baranda 3 TON [2 h]; Camión Cisterna 4x2 400 HP Agua (5000 gal) [3 h]; Camión grua [3 h]; Camión Plataforma 4x2 122 HP [1 h]; Camión Volquete (15 m3) [15 h]; Cargador Frontal 195 HP [2 h]; CARGADOR SOBRE LLANTAS DE 200-250 HP [2 h]; Excavadora Sobre Oruga 260 HP [10 h]; Motoniveladora 185 HP [4 h]; Retroexcavador 58 HP [3 h]; Rodillo Vib. Liso Autopropulsado 135 HP 12 TM [4 h]; Tractor S/Orugas (D6T) - 180 HP [5 h]; Camión Volquete Roquero (15 m3) [20 h] |
| 01.02.02 |  | TOPOGRAFÍA Y GEOREFERENCIACIÓN |  | 136.53d | 2024-01-06 | 2024-06-17 | 1.01.01 SS, 1.07.110 SS | 5.98d | 6d |  | AYUDANTE DE NIVELADOR [3600.48 h]; AYUDANTE DE TOPOGRAFO [3600.48 h]; TOPOGRAFO [2400.32 h]; OP. NIVELADOR [1200.16 h] |
|  | 3 | **DIQUES DE TIERRA COMPACTADA CON ENROCADO** |  |  | 2024-02-23 | 2024-06-15 |  |  |  |  |  |
|  | 1 | **DIQUE DE TIERRA COMPACTADA A1-D-02** |  |  | 2024-03-01 | 2024-03-23 |  |  |  |  |  |
| 1.03.01 |  | COLOCACION Y ACOMODO DE ROCA EN UÑA DE DIQUE |  | 12.5d | 2024-03-01 | 2024-03-15 | 1.07.634 FS+0.5d | 73.97d | 0d |  | CAPATAZ [82.29 h]; OPERARIO [82.29 h]; PEON [411.7 h]; Excavadora Sobre Oruga 260 HP [123.5 h] |
| 1.03.02 |  | COLOCACION Y ACOMODO DE ROCA EN TALUD DE DIQUE |  | 9.5d | 2024-03-13 | 2024-03-23 | 1.03.01 FS-2.5d | 73.97d | 0d |  | CAPATAZ [63.85 h]; PEON [382.94 h]; Excavadora Sobre Oruga 260 HP [95.73 h]; OPERARIO [63.85 h] |

| ID | WBS | Activity | Duration | Start | Finish | Predecessors | Total float | Free float | Resources |
| --- | --- | --- | --- | --- | --- | --- | --- | --- | --- |
|  | 2 | **DIQUE DE TIERRA COMPACTADA A1-I-02** |  | 2024-02-23 | 2024-03-16 |  |  |  |  |
| 1.03.03 |  | COLOCACION Y ACOMODO DE ROCA EN UÑA DE DIQUE | 12.5d | 2024-02-23 | 2024-03-08 | 1.07.630 FS+0.5d | 79.31d | 0d | CAPATAZ [82.24 h]; OPERARIO [82.24 h]; PEON [411.47 h]; Excavadora Sobre Oruga 260 HP [123.43 h] |
| 1.03.04 |  | COLOCACION Y ACOMODO DE ROCA EN TALUD DE DIQUE | 9.5d | 2024-03-06 | 2024-03-16 | 1.03.03 FS-2.5d | 79.31d | 0d | CAPATAZ [64.04 h]; PEON [384.06 h]; Excavadora Sobre Oruga 260 HP [96.01 h]; OPERARIO [64.04 h] |
|  | 3 | **DIQUE DE TIERRA COMPACTADA A1-D-01** |  | 2024-05-13 | 2024-06-15 |  |  |  |  |
| 1.03.05 |  | COLOCACION Y ACOMODO DE ROCA EN UÑA DE DIQUE | 22.5d | 2024-05-13 | 2024-06-07 | 1.07.636 FS-4.5d | -0.02d | 0d | CAPATAZ [598.55 h]; OPERARIO [598.55 h]; PEON [2994.72 h]; Excavadora Sobre Oruga 260 HP [898.32 h] |
| 1.03.06 |  | COLOCACION Y ACOMODO DE ROCA EN TALUD DE DIQUE | 15.5d | 2024-05-29 | 2024-06-15 | 1.03.05 FS-8.5d | -0.02d | 0d | CAPATAZ [420.38 h]; PEON [2521.02 h]; Excavadora Sobre Oruga 260 HP [630.26 h]; OPERARIO [420.38 h] |
|  | 4 | **DIQUE DE TIERRA COMPACTADA A1-I-01** |  | 2024-04-17 | 2024-05-25 |  |  |  |  |
| 1.03.07 |  | COLOCACION Y ACOMODO DE ROCA EN UÑA DE DIQUE | 24.5d | 2024-04-17 | 2024-05-16 | 1.07.632 FS-6.5d | 1.96d | 0d | CAPATAZ [650.61 h]; OPERARIO [650.61 h]; PEON [3255.14 h]; Excavadora Sobre Oruga 260 HP [976.44 h] |
| 1.03.08 |  | COLOCACION Y ACOMODO DE ROCA EN TALUD DE DIQUE | 17.5d | 2024-05-06 | 2024-05-25 | 1.03.07 FS-9.5d | 1.96d | 0d | CAPATAZ [472.77 h]; PEON [2835.23 h]; Excavadora Sobre Oruga 260 HP [708.81 h]; OPERARIO [472.77 h] |
|  | 8 | **OBRAS DE ARTE (REBOSES)** |  | 2024-01-30 | 2024-03-02 |  |  |  |  |
|  | 1 | **ESTRUCTURA DE REBOSE** |  | 2024-01-30 | 2024-03-02 |  |  |  |  |
|  | 1 | **OBRAS DE CONCRETO** |  | 2024-02-09 | 2024-03-02 |  |  |  |  |
| 1.04.01 |  | CONCRETO f'c=100 kg/cm2 | 0.53d | 2024-02-09 | 2024-02-10 | 1.08.04 FS+0.5d | 94.22d | 0d | CAPATAZ [0.11 h]; OPERARIO [2.15 h]; PEON [4.29 h]; OFICIAL [1.07 h] |
| 1.04.04 |  | ACERO DE REFUERZO fy=4200 kg/cm2 | 11.5d | 2024-02-10 | 2024-02-24 | 1.04.01 FS+0.5d | 94.22d | 0d | CAPATAZ [18.87 h]; OPERARIO [188.73 h]; PEON [188.73 h] |
| 1.04.03 |  | ENCOFRADO Y DESENCOFRADO RECTO | 13.5d | 2024-02-14 | 2024-02-29 | 1.04.04 FS-8.9d | 94.22d | 0d | CAPATAZ [111.67 h]; OPERARIO [223.37 h]; PEON [223.37 h] |
| 1.04.02 |  | CONCRETO f'c=280 kg/cm2 | 1.5d | 2024-03-01 | 2024-03-02 | 1.04.03 FS+0.5d | 94.22d | 94.25d | CAPATAZ [0.88 h]; OPERARIO [17.66 h]; PEON [35.31 h]; OFICIAL [8.83 h] |
|  | 2 | **TUBERÍAS** |  | 2024-01-30 | 2024-02-01 |  |  |  |  |
| 1.04.05 |  | SUMINISTRO E INSTALACIÓN DE TUBERÍA HDPE DN800 mm | 0.53d | 2024-01-30 | 2024-01-30 | 1.08.03 FS+0.53d | 94.22d | 0d | CAPATAZ [0.1 h]; OPERARIO [0.96 h]; PEON [2.87 h]; Retroexcavador 58 HP [0.96 h] |
| 1.04.06 |  | SUMINISTRO E INSTALACIÓN DE TUBERÍA HDPE DN1000 mm | 0.53d | 2024-01-31 | 2024-02-01 | 1.04.05 FS+0.53d | 94.22d | 0d | CAPATAZ [0.31 h]; OPERARIO [3.12 h]; PEON [9.35 h]; Retroexcavador 58 HP [3.12 h] |
|  | 9 | **INTERFERENCIAS** |  | 2024-01-11 | 2024-06-20 |  |  |  |  |
|  | 1 | **CANAL A REPONER DE SECCIÓN RECTANGULAR** |  | 2024-05-23 | 2024-06-20 |  |  |  |  |
|  | 1 | **OBRAS DE CONCRETO** |  | 2024-05-23 | 2024-06-20 |  |  |  |  |
| 1.04.09 |  | CONCRETO f'c=100 kg/cm2 | 0.53d | 2024-05-23 | 2024-05-23 | 1.09.02 FS+0.53d | 1.96d | 0d | CAPATAZ [0.32 h]; OPERARIO [6.32 h]; PEON [12.63 h]; OFICIAL [3.16 h] |
| 1.04.08 |  | ACERO DE REFUERZO fy=4200 kg/cm2 | 7.5d | 2024-05-24 | 2024-06-01 | 1.04.09 FS+0.5d | 1.96d | 0d | CAPATAZ [34.14 h]; OPERARIO [341.38 h]; PEON [341.38 h] |
| 1.04.07 |  | ENCOFRADO Y DESENCOFRADO RECTO | 19.5d | 2024-05-25 | 2024-06-17 | 1.04.08 FS-6.5d | 1.96d | 0d | CAPATAZ [476.22 h]; OPERARIO [952.58 h]; PEON [952.58 h] |
| 1.04.10 |  | CONCRETO f'c=280 kg/cm2 | 2.5d | 2024-06-18 | 2024-06-20 | 1.04.07 FS+0.5d | 1.96d | 0d | CAPATAZ [2.16 h]; OPERARIO [43.29 h]; PEON [86.57 h]; OFICIAL [21.65 h] |
| 1.04.11 |  | SELLO DE JUNTAS CON WATER STOP 6" | 2.5d | 2024-06-18 | 2024-06-20 | 1.04.10 SS | 2.96d | 2.98d | OPERARIO [21.84 h]; PEON [87.36 h] |

| ID | WBS | Activity | Duration | Start | Finish | Predecessors | Total float | Free float | Resources |
| --- | --- | --- | --- | --- | --- | --- | --- | --- | --- |
|  | 2 | **CANAL A REPONER DE SECCION TRAPEZOIDAL** |  | 2024-05-30 | 2024-06-12 |  |  |  |  |
|  | 1 | **OBRAS DE CONCRETO** |  | 2024-05-30 | 2024-06-12 |  |  |  |  |
| 1.04.12 |  | ENCOFRADO Y DESENCOFRADO RECTO | 8.5d | 2024-05-30 | 2024-06-08 | 1.09.06 FS+0.5d | 8.96d | 0d | CAPATAZ [208.6 h]; OPERARIO [417.25 h]; PEON [417.25 h] |
| 1.04.15 |  | SELLO DE JUNTAS CON MATERIAL ELASTOMÉRICO | 5.5d | 2024-06-03 | 2024-06-08 | 1.04.12 FS-5.5d | 13.02d | 13.04d | CAPATAZ [16.47 h]; OFICIAL [164.74 h]; PEON [164.74 h] |
| 1.04.13 |  | ENCOFRADO Y DESENCOFRADO CERCHAS DE MADERA | 1.5d | 2024-06-07 | 2024-06-08 | 1.04.12 FS-1.5d | 8.96d | 0d | CAPATAZ [12.25 h]; OPERARIO [24.49 h]; PEON [24.49 h] |
| 1.04.14 |  | CONCRETO f'c=280 kg/cm2 | 2.5d | 2024-06-10 | 2024-06-12 | 1.04.13 FS+0.5d | 8.96d | 0d | CAPATAZ [1.44 h]; OPERARIO [28.75 h]; PEON [57.48 h]; OFICIAL [14.37 h] |
|  | 3 | **AFECTACIÓN A ESTRUCTURAS PRIVADAS** |  | 2024-01-11 | 2024-02-02 |  |  |  |  |
|  | 1 | **MOVIMIENTO DE TIERRAS** |  | 2024-01-11 | 2024-01-27 |  |  |  |  |
| 1.04.16 |  | DEMOLICIÓN DE ESTRUCTURAS EXISTENTES | 7.5d | 2024-01-11 | 2024-01-19 | 1.01.02 FS+0.5d | 118.88d | 0d | CAPATAZ [17.98 h]; OPERARIO [359.64 h]; PEON [539.45 h]; Excavadora + Martillo hidraúlico [179.82 h] |
| 1.04.17 |  | ELIMINACIÓN DE PRODUCTOS DE DEMOLICIÓN DE OBRAS DE CONCRETO | 13.5d | 2024-01-12 | 2024-01-27 | 1.04.16 FS-6.5d | 118.88d | 0d | CAPATAZ [20.25 h]; OPERARIO [202.32 h]; PEON [202.32 h]; Excavadora + Martillo hidraúlico [202.32 h] |
|  | 2 | **REPOSICIÓN DE TUBERÍAS DE PASO** |  | 2024-01-29 | 2024-01-31 |  |  |  |  |
| 1.04.18 |  | REPOSICIÓN DE TUBERÍAS DE HDPE DE 4" | 0.53d | 2024-01-29 | 2024-01-29 | 1.04.17 FS+0.5d | 118.88d | 0d | CAPATAZ [0.8 h]; OPERARIO [8 h]; PEON [16 h]; Retroexcavador 58 HP [8 h] |
| 1.04.19 |  | REPOSICIÓN DE TUBERÍAS DE HDPE DE 6" | 0.53d | 2024-01-30 | 2024-01-30 | 1.04.18 FS+0.53d | 118.88d | 0d | CAPATAZ [0.4 h]; OPERARIO [4 h]; PEON [8 h]; Retroexcavador 58 HP [4 h] |
| 1.04.20 |  | REPOSICIÓN DE TUBERÍAS DE HDPE DE 8" | 0.53d | 2024-01-31 | 2024-01-31 | 1.04.19 FS+0.53d | 118.88d | 0d | CAPATAZ [0.8 h]; OPERARIO [8 h]; PEON [16 h]; Retroexcavador 58 HP [8 h] |
|  | 3 | **REUBICACIÓN DE INTERFERENCIAS** |  | 2024-02-01 | 2024-02-02 |  |  |  |  |
| 1.04.21 |  | DEMOLICIÓN DE INTERFERENCIAS SIMA | 0.5d | 2024-02-01 | 2024-02-01 | 1.04.20 FS+0.5d | 118.88d | 0d | CAPATAZ [0.04 h]; OPERARIO [0.8 h]; PEON [1.2 h]; Excavadora + Martillo hidraúlico [0.4 h] |
| 1.04.22 |  | ELIMINACIÓN DE INTERFERENCIAS SIMA | 0.5d | 2024-02-02 | 2024-02-02 | 1.04.21 FS+0.5d | 118.88d | 118.91d | CAPATAZ [0.01 h]; OPERARIO [0.14 h]; PEON [0.14 h]; Excavadora + Martillo hidraúlico [0.14 h] |
|  | 2 | **SUBPROYECTO A1 (OPCIÓN B)** |  | 2023-12-27 | 2024-06-24 |  |  |  |  |
|  | 1 | **DEFENSAS RIBEREÑAS** |  | 2023-12-27 | 2024-06-21 |  |  |  |  |
|  | 1 | **MEJORAMIENTO DE VÍAS EXISTENTES** |  | 2023-12-27 | 2024-01-03 |  |  |  |  |
| 1.06.01 |  | REHABILITACIÓN DE VÍAS EXISTENTES | 5.5d | 2023-12-27 | 2024-01-03 | 01.02.01 SS+7.41d | 144.97d | 144.99d | CAPATAZ [1.46 h]; CUADRADOR/VIGÍA [14.6 h]; Tractor S/Orugas (D6T) - 180 HP [21.9 h]; Camión Cisterna 4x2 400 HP Agua (5000 gal) [14.6 h]; OPERARIO [14.6 h]; Excavadora Sobre Oruga 260 HP [14.6 h]; Motoniveladora 185 HP [7.3 h]; Rodillo Vib. Liso Autopropulsado 135 HP 12 TM [7.3 h] |
|  | 2 | **DESCOLMATACIÓN DE CAUCE** |  | 2023-12-27 | 2024-02-26 |  |  |  |  |
| 1.07.01 |  | DESBROCE Y LIMPIEZA EN ZONA NO BOSCOSA - MARGEN IZQUIERDA | 6.5d | 2023-12-27 | 2024-01-04 | 01.02.01 SS+7.41d | 0.41d | 0d | Camión Volquete (15 m3) [98.08 h]; Excavadora Sobre Oruga 260 HP [54.49 h]; OPERARIO [98.08 h]; PEON [610.28 h]; Tractor S/Orugas (D6T) - 180 HP [98.08 h] |
| 1.07.03 |  | DESCOLMATACIÓN DE CAUCE NATURAL DEL RÍO LACRAMARCA PROG: KM 03+300 A KM 01+650 | 20.5d | 2023-12-27 | 2024-01-20 | 1.07.01 SS | 0.41d | 0d | CUADRADOR/VIGÍA [337.5 h]; Excavadora Sobre Oruga 260 HP [337.5 h]; PEON [674.99 h]; Tractor S/Orugas (D6T) - 180 HP [337.5 h]; CAPATAZ [32.14 h] |
| 1.07.02 |  | DESBROCE Y LIMPIEZA EN ZONA NO BOSCOSA - MARGEN DERECHA | 13.5d | 2024-01-05 | 2024-01-20 | 1.07.01 SS+6.6d | 94.22d | 0d | Camión Volquete (15 m3) [98.08 h]; Excavadora Sobre Oruga 260 HP [54.49 h]; OPERARIO [98.08 h]; PEON [610.28 h]; Tractor S/Orugas (D6T) - 180 HP [98.08 h] |
| 1.07.04 |  | DESCOLMATACIÓN DE CAUCE NATURAL DEL RÍO LACRAMARCA PROG: KM 01+650 A KM 00+000 | 20.5d | 2024-01-22 | 2024-02-14 | 1.07.03 FS+0.53d | 0.41d | 0d | CUADRADOR/VIGÍA [337.5 h]; Excavadora Sobre Oruga 260 HP [337.5 h]; PEON [674.99 h]; Tractor S/Orugas (D6T) - 180 HP [337.5 h]; CAPATAZ [32.14 h] |
| 1.07.05 |  | CONFORMACIÓN DE DESVIO EN CAUCE DE RÍO | 17.5d | 2024-02-06 | 2024-02-26 | 1.07.04 FS-7.5d | 0.41d | 0.44d | CAPATAZ [114.41 h]; CUADRADOR/VIGÍA [114.41 h]; Excavadora Sobre Oruga 260 HP [114.41 h]; OPERARIO [114.41 h]; Tractor S/Orugas (D6T) - 180 HP [56.35 h] |

| ID | WBS | Activity | Duration | Start | Finish | Predecessors | Total float | Free float | Resources |
| --- | --- | --- | --- | --- | --- | --- | --- | --- | --- |
|  | 3 | **DIQUES DE TIERRA COMPACTADA CON ENROCADO** |  | 2024-01-06 | 2024-06-21 |  |  |  |  |
|  | 1 | **EXCAVACIÓN EN TERRENO NATURAL CON EQUIPO** |  | 2024-01-06 | 2024-03-16 |  |  |  |  |
| 1.07.110 |  | EXCAVACIÓN EN TERRENO NATURAL CON EQUIPO A1-I-02 | 11.5d | 2024-01-06 | 2024-01-19 | A1040 SS-0.1d, A1054 SS-0.4d | -0.02d | 0d | CAPATAZ [18.01 h]; PEON [180.11 h]; Tractor S/Orugas (D6T) - 180 HP [180.11 h]; Excavadora Sobre Oruga 260 HP [180.11 h] |
| 1.07.114 |  | EXCAVACIÓN EN TERRENO NATURAL CON EQUIPO A1-D-02 | 9.53d | 2024-01-16 | 2024-01-26 | 1.07.110 FS-3.5d, A1055 SS-0.4d | 5.32d | 0d | CAPATAZ [14.74 h]; PEON [147.39 h]; Tractor S/Orugas (D6T) - 180 HP [147.39 h]; Excavadora Sobre Oruga 260 HP [147.39 h] |
| 1.07.112 |  | EXCAVACIÓN EN TERRENO NATURAL CON EQUIPO A1-I-01 | 33.5d | 2024-01-20 | 2024-02-28 | 1.07.110 FS+0.5d, 1.07.05 FF+1.5d | -0.02d | 0d | CAPATAZ [107.53 h]; PEON [1075.31 h]; Tractor S/Orugas (D6T) - 180 HP [1075.31 h]; Excavadora Sobre Oruga 260 HP [1075.31 h] |
| 1.07.118 |  | EXCAVACIÓN EN TERRENO NATURAL CON EQUIPO RAMPAS | 0.53d | 2024-01-27 | 2024-01-27 | 1.07.114 FS+0.53d | 5.32d | 0.01d | CAPATAZ [0.08 h]; PEON [0.8 h]; Tractor S/Orugas (D6T) - 180 HP [0.8 h]; Excavadora Sobre Oruga 260 HP [0.8 h] |
| 1.07.116 |  | EXCAVACIÓN EN TERRENO NATURAL CON EQUIPO A1-D-01 | 27.5d | 2024-02-14 | 2024-03-16 | 1.07.112 FS-12.5d | -0.02d | 0d | CAPATAZ [86.68 h]; PEON [866.81 h]; Tractor S/Orugas (D6T) - 180 HP [866.81 h]; Excavadora Sobre Oruga 260 HP [866.81 h] |
|  | 2 | **EXCAVACIÓN DE UÑA CON EQUIPO** |  | 2024-01-17 | 2024-03-16 |  |  |  |  |
| 1.07.120 |  | EXCAVACIÓN DE UÑA CON EQUIPO A1-I-02 | 2.5d | 2024-01-17 | 2024-01-19 | 1.07.110 FS-2.4d | 12.01d | 0d | CAPATAZ [2.14 h]; Excavadora Sobre Oruga 260 HP [21.41 h]; PEON [21.41 h] |
| 1.07.124 |  | EXCAVACIÓN DE UÑA CON EQUIPO A1-D-02 | 2.5d | 2024-01-24 | 2024-01-26 | 1.07.114 FS-2.49d | 73.97d | 0d | CAPATAZ [2.14 h]; Excavadora Sobre Oruga 260 HP [21.4 h]; PEON [21.4 h] |
| 1.07.122 |  | EXCAVACIÓN DE UÑA CON EQUIPO A1-I-01 | 10.5d | 2024-02-16 | 2024-02-28 | 1.07.112 FS-10.5d | 1.96d | 0d | CAPATAZ [16.93 h]; Excavadora Sobre Oruga 260 HP [169.35 h]; PEON [169.35 h] |
| 1.07.126 |  | EXCAVACIÓN DE UÑA CON EQUIPO A1-D-01 | 9.5d | 2024-03-06 | 2024-03-16 | 1.07.116 FS-9.5d | -0.02d | 0d | CAPATAZ [15.57 h]; Excavadora Sobre Oruga 260 HP [155.72 h]; PEON [155.72 h] |
|  | 3 | **PERFILADO Y COMPACTACIÓN EN ZONA DE CORTE** |  | 2024-01-20 | 2024-03-23 |  |  |  |  |
| 1.07.130 |  | PERFILADO Y COMPACTACIÓN EN ZONA DE CORTE A1-I-02 | 2.5d | 2024-01-20 | 2024-01-23 | 1.07.120 FS+0.5d | 12.01d | 0d | CAPATAZ [1.83 h]; Excavadora Sobre Oruga 260 HP [4.88 h]; PEON [19.51 h]; Rodillo Vib. Liso Autopropulsado 135 HP 12 TM [19.51 h]; Motoniveladora 185 HP [9.75 h]; Camión Cisterna 4x2 400 HP Agua (5000 gal) [4.88 h] |
| 1.07.134 |  | PERFILADO Y COMPACTACIÓN EN ZONA DE CORTE A1-D-02 | 2.5d | 2024-01-27 | 2024-01-30 | 1.07.124 FS+0.5d | 73.97d | 0d | CAPATAZ [1.76 h]; Excavadora Sobre Oruga 260 HP [4.69 h]; PEON [18.74 h]; Rodillo Vib. Liso Autopropulsado 135 HP 12 TM [18.74 h]; Motoniveladora 185 HP [9.37 h]; Camión Cisterna 4x2 400 HP Agua (5000 gal) [4.69 h] |
| 1.07.132 |  | PERFILADO Y COMPACTACIÓN EN ZONA DE CORTE A1-I-01 | 12.5d | 2024-02-23 | 2024-03-08 | 1.07.122 FS-4.5d | 1.96d | 0d | CAPATAZ [16.06 h]; Excavadora Sobre Oruga 260 HP [42.83 h]; PEON [171.31 h]; Rodillo Vib. Liso Autopropulsado 135 HP 12 TM [171.31 h]; Motoniveladora 185 HP [85.65 h]; Camión Cisterna 4x2 400 HP Agua (5000 gal) [42.83 h] |
| 1.07.136 |  | PERFILADO Y COMPACTACIÓN EN ZONA DE CORTE A1-D-01 | 9.5d | 2024-03-13 | 2024-03-23 | 1.07.126 FS-3.5d | -0.02d | 0d | CAPATAZ [13.16 h]; Excavadora Sobre Oruga 260 HP [35.1 h]; PEON [140.4 h]; Rodillo Vib. Liso Autopropulsado 135 HP 12 TM [140.4 h]; Motoniveladora 185 HP [70.2 h]; Camión Cisterna 4x2 400 HP Agua (5000 gal) [35.1 h] |
|  | 4 | **PEDRAPLÉN e=60 cm** |  | 2024-01-24 | 2024-04-05 |  |  |  |  |
| 1.07.410 |  | PEDRAPLÉN e=60 cm A1-I-02 | 7.5d | 2024-01-24 | 2024-02-01 | 1.07.130 FS+0.5d | 12.01d | 0d | CAPATAZ [12.38 h]; OPERARIO [122.42 h]; PEON [1222.79 h]; OFICIAL [122.42 h]; CARGADOR SOBRE LLANTAS DE 200-250 HP [122.42 h]; Excavadora Sobre Oruga 320 [122 h] |
| 1.07.414 |  | PEDRAPLÉN e=60 cm A1-D-02 | 7.5d | 2024-01-31 | 2024-02-08 | 1.07.134 FS+0.5d | 73.97d | 0d | CAPATAZ [11.45 h]; OPERARIO [113.27 h]; PEON [1131.41 h]; OFICIAL [113.27 h]; CARGADOR SOBRE LLANTAS DE 200-250 HP [113.27 h]; Excavadora Sobre Oruga 320 [113 h] |
| 1.07.412 |  | PEDRAPLÉN e=60 cm A1-I-01 | 14.5d | 2024-03-05 | 2024-03-21 | 1.07.132 FS-3.7d | 1.96d | 0d | CAPATAZ [46.77 h]; OPERARIO [462.54 h]; PEON [4620.23 h]; OFICIAL [462.54 h]; CARGADOR SOBRE LLANTAS DE 200-250 HP [462.54 h]; Excavadora Sobre Oruga 320 [463 h] |
| 1.07.416 |  | PEDRAPLÉN e=60 cm A1-D-01 | 13.5d | 2024-03-19 | 2024-04-05 | 1.07.136 FS-4.5d | -0.02d | 0d | CAPATAZ [44.97 h]; OPERARIO [444.69 h]; PEON [4441.94 h]; OFICIAL [444.69 h]; CARGADOR SOBRE LLANTAS DE 200-250 HP [444.69 h]; Excavadora Sobre Oruga 320 [445 h] |
|  | 5 | **PEDRAPLÉN e=30 cm** |  | 2024-02-02 | 2024-04-11 |  |  |  |  |
| 1.07.510 |  | PEDRAPLÉN e=30 cm A1-I-02 | 1.5d | 2024-02-02 | 2024-02-03 | 1.07.410 FS+0.5d | 79.31d | 0d | CAPATAZ [2.1 h]; Motoniveladora 185 HP [20.74 h]; OPERARIO [20.74 h]; PEON [207.21 h]; OFICIAL [20.74 h]; CARGADOR SOBRE LLANTAS DE 200-250 HP [20.74 h]; Excavadora Sobre Oruga 320 [20 h] |
| 1.07.514 |  | PEDRAPLÉN e=30 cm A1-D-02 | 1.5d | 2024-02-09 | 2024-02-10 | 1.07.414 FS+0.5d | 73.97d | 0d | CAPATAZ [2.05 h]; Motoniveladora 185 HP [20.32 h]; OPERARIO [20.32 h]; PEON [202.99 h]; OFICIAL [20.32 h]; CARGADOR SOBRE LLANTAS DE 200-250 HP [20.32 h]; Excavadora Sobre Oruga 320 [20 h] |
| 1.07.512 |  | PEDRAPLÉN e=30 cm A1-I-01 | 10.5d | 2024-03-13 | 2024-03-25 | 1.07.412 FS-7.41d | 1.96d | 0d | CAPATAZ [17.09 h]; Motoniveladora 185 HP [169.03 h]; OPERARIO [169.03 h]; PEON [1688.35 h]; OFICIAL [169.03 h]; CARGADOR SOBRE LLANTAS DE 200-250 HP [169.03 h]; Excavadora Sobre Oruga 320 [20 h] |
| 1.07.516 |  | PEDRAPLÉN e=30 cm A1-D-01 | 9.53d | 2024-04-01 | 2024-04-11 | 1.07.416 FS-4.5d | -0.02d | 0d | CAPATAZ [16.15 h]; Motoniveladora 185 HP [159.7 h]; OPERARIO [159.7 h]; PEON [1595.2 h]; OFICIAL [159.7 h]; CARGADOR SOBRE LLANTAS DE 200-250 HP [159.7 h]; Excavadora Sobre Oruga 320 [20 h] |

| ID | WBS | Activity | Duration | Start | Finish | Predecessors | Total float | Free float | Resources |
| --- | --- | --- | --- | --- | --- | --- | --- | --- | --- |
|  | 6 | **CONFORMACIÓN DE CUERPO DE DIQUE CON MATERIAL DE PRÉSTAMO** |  | 2024-01-29 | 2024-04-27 |  |  |  |  |
| 1.07.618 |  | CONFORMACIÓN DE CUERPO DE RAMPA CON MATERIAL DE PRESTAMO | 0.53d | 2024-01-29 | 2024-01-29 | 1.07.118 FS+0.5d, A1050 SS | 5.31d | 0d | Camión Cisterna 4x2 400 HP Agua (5000 gal) [1.48 h]; CAPATAZ [2.98 h]; Motoniveladora 185 HP [2.98 h]; OPERARIO [2.98 h]; PEON [11.9 h]; Rodillo Vib. Liso Autopropulsado 135 HP 12 TM [86.08 h]; OFICIAL [2.98 h]; Excavadora Sobre Oruga 260 HP [2.98 h]; CARGADOR SOBRE LLANTAS DE 200-250 HP [1.48 h] |
| 1.07.610 |  | CONFORMACIÓN DE CUERPO DE DIQUE CON MATERIAL DE PRÉSTAMO A1-I-02 | 8.5d | 2024-02-05 | 2024-02-14 | 1.07.510 FS+0.5d | 79.31d | 0d | Camión Cisterna 4x2 400 HP Agua (5000 gal) [64.55 h]; CAPATAZ [129.58 h]; Motoniveladora 185 HP [129.58 h]; OPERARIO [129.58 h]; PEON [517.83 h]; Rodillo Vib. Liso Autopropulsado 135 HP 12 TM [129.58 h]; OFICIAL [129.58 h]; Excavadora Sobre Oruga 260 HP [129.58 h]; CARGADOR SOBRE LLANTAS DE 200-250 HP [64.55 h] |
| 1.07.614 |  | CONFORMACIÓN DE CUERPO DE DIQUE CON MATERIAL DE PRÉSTAMO A1-D-02 | 8.5d | 2024-02-12 | 2024-02-21 | 1.07.514 FS+0.5d | 73.97d | 0d | Camión Cisterna 4x2 400 HP Agua (5000 gal) [63.94 h]; CAPATAZ [128.35 h]; Motoniveladora 185 HP [128.35 h]; OPERARIO [128.35 h]; PEON [512.94 h]; Rodillo Vib. Liso Autopropulsado 135 HP 12 TM [128.35 h]; OFICIAL [128.35 h]; Excavadora Sobre Oruga 260 HP [128.35 h]; CARGADOR SOBRE LLANTAS DE 200-250 HP [63.94 h] |
| 1.07.612 |  | CONFORMACIÓN DE CUERPO DE DIQUE CON MATERIAL DE PRÉSTAMO A1-I-01 | 20.5d | 2024-03-20 | 2024-04-15 | 1.07.512 FS-4.5d | 1.96d | 0d | Camión Cisterna 4x2 400 HP Agua (5000 gal) [323.17 h]; CAPATAZ [648.76 h]; Motoniveladora 185 HP [648.76 h]; OPERARIO [648.76 h]; PEON [2592.63 h]; Rodillo Vib. Liso Autopropulsado 135 HP 12 TM [648.76 h]; OFICIAL [648.76 h]; Excavadora Sobre Oruga 260 HP [648.76 h]; CARGADOR SOBRE LLANTAS DE 200-250 HP [323.17 h] |
| 1.07.616 |  | CONFORMACIÓN DE CUERPO DE DIQUE CON MATERIAL DE PRÉSTAMO A1-D-01 | 19.5d | 2024-04-05 | 2024-04-27 | 1.07.516 FS-5.5d | -0.02d | 0d | Camión Cisterna 4x2 400 HP Agua (5000 gal) [315.66 h]; CAPATAZ [633.7 h]; Motoniveladora 185 HP [633.7 h]; OPERARIO [633.7 h]; PEON [2532.42 h]; Rodillo Vib. Liso Autopropulsado 135 HP 12 TM [633.7 h]; OFICIAL [633.7 h]; Excavadora Sobre Oruga 260 HP [633.7 h]; CARGADOR SOBRE LLANTAS DE 200-250 HP [315.66 h] |
|  | 7 | **CONFORMACIÓN DE RELLENO NO ESTRUCTURAL CON MATERIAL PROPIO** |  | 2024-02-15 | 2024-04-27 |  |  |  |  |
| 1.07.620 |  | CONFORMACIÓN DE RELLENO NO ESTRUCTURAL CON MATERIAL PROPIO A1-I-02 | 1.5d | 2024-02-15 | 2024-02-16 | 1.07.610 FS+0.5d | 79.31d | 0d | Camión Cisterna 4x2 400 HP Agua (5000 gal) [10.15 h]; CAPATAZ [5.07 h]; OPERARIO [10.15 h]; PEON [20.52 h]; Rodillo Vib. Liso Autopropulsado 135 HP 12 TM [10.15 h]; Tractor S/Orugas (D6T) - 180 HP [10.15 h] |
| 1.07.624 |  | CONFORMACIÓN DE RELLENO NO ESTRUCTURAL CON MATERIAL PROPIO A1-D-02 | 1.5d | 2024-02-22 | 2024-02-23 | 1.07.614 FS+0.5d | 73.97d | 0d | Camión Cisterna 4x2 400 HP Agua (5000 gal) [8.94 h]; CAPATAZ [4.47 h]; OPERARIO [8.94 h]; PEON [18.09 h]; Rodillo Vib. Liso Autopropulsado 135 HP 12 TM [8.94 h]; Tractor S/Orugas (D6T) - 180 HP [8.94 h] |
| 1.07.622 |  | CONFORMACIÓN DE RELLENO NO ESTRUCTURAL CON MATERIAL PROPIO A1-I-01 | 4.5d | 2024-04-13 | 2024-04-18 | 1.07.612 FS-1.5d | 7.06d | 5.1d | Camión Cisterna 4x2 400 HP Agua (5000 gal) [36.69 h]; CAPATAZ [18.35 h]; OPERARIO [36.69 h]; PEON [74.21 h]; Rodillo Vib. Liso Autopropulsado 135 HP 12 TM [36.69 h]; Tractor S/Orugas (D6T) - 180 HP [36.69 h] |
| 1.07.626 |  | CONFORMACIÓN DE RELLENO NO ESTRUCTURAL CON MATERIAL PROPIO A1-D-01 | 2.5d | 2024-04-25 | 2024-04-27 | 1.07.616 FS-2.5d | -0.02d | 0d | Camión Cisterna 4x2 400 HP Agua (5000 gal) [21.49 h]; CAPATAZ [10.74 h]; OPERARIO [21.49 h]; PEON [43.47 h]; Rodillo Vib. Liso Autopropulsado 135 HP 12 TM [21.49 h]; Tractor S/Orugas (D6T) - 180 HP [21.49 h] |
|  | 8 | **GEOTEXTIL NO TEJIDO 400 G/M2, INC. COLOCACIÓN** |  | 2024-02-17 | 2024-05-17 |  |  |  |  |
| 1.07.630 |  | GEOTEXTIL NO TEJIDO 400 G/M2, INC. COLOCACIÓN A1-I-02 | 4.5d | 2024-02-17 | 2024-02-22 | 1.07.620 FS+0.5d | 79.31d | 0d | CAPATAZ [6.44 h]; OPERARIO [64.39 h]; PEON [257.56 h] |
| 1.07.634 |  | GEOTEXTIL NO TEJIDO 400 G/M2, INC. COLOCACIÓN A1-D-02 | 4.5d | 2024-02-24 | 2024-02-29 | 1.07.624 FS+0.5d | 73.97d | 0d | CAPATAZ [6.94 h]; OPERARIO [69.35 h]; PEON [277.41 h] |
| 1.07.632 |  | GEOTEXTIL NO TEJIDO 400 G/M2, INC. COLOCACIÓN A1-I-01 | 17.5d | 2024-04-04 | 2024-04-24 | 1.07.612 FS-9.4d, 1.07.622 FF | 1.96d | 0d | CAPATAZ [57.2 h]; OPERARIO [571.98 h]; PEON [2287.91 h] |
| 1.07.636 |  | GEOTEXTIL NO TEJIDO 400 G/M2, INC. COLOCACIÓN A1-D-01 | 16.5d | 2024-04-27 | 2024-05-17 | 1.07.626 FS-0.5d | -0.02d | 0d | CAPATAZ [52.77 h]; OPERARIO [527.67 h]; PEON [2110.66 h] |
|  | 9 | **CONFORMACIÓN DE MATERIAL GRANULAR EN CORONA DE DIQUE** |  | 2024-01-30 | 2024-06-21 |  |  |  |  |
| 1.07.648 |  | CONFORMACIÓN DE MATERIAL GRANULAR EN CORONA | 0.5d | 2024-01-30 | 2024-01-30 | 1.07.618 FS+0.5d | 121.88d | 121.91d | Camión Cisterna 4x2 400 HP Agua (5000 gal) [2.15 h]; CAPATAZ [4.29 h]; Motoniveladora 185 HP [4.29 h]; OPERARIO [4.29 h]; PEON [17.15 h]; Rodillo Vib. Liso Autopropulsado 135 HP 12 TM [4.29 h]; OFICIAL [4.29 h]; Excavadora Sobre Oruga 260 HP [4.29 h]; CARGADOR SOBRE LLANTAS DE 200-250 HP [2.15 h] |
| 1.07.640 |  | CONFORMACIÓN DE MATERIAL GRANULAR EN CORONA DE DIQUE A1-I-02 | 2.5d | 2024-03-18 | 2024-03-20 | 1.03.04 FS+0.1d | 79.31d | 79.33d | Camión Cisterna 4x2 400 HP Agua (5000 gal) [3.26 h]; CAPATAZ [6.53 h]; Motoniveladora 185 HP [6.53 h]; OPERARIO [6.53 h]; PEON [26.09 h]; Rodillo Vib. Liso Autopropulsado 135 HP 12 TM [6.53 h]; OFICIAL [6.53 h]; Excavadora Sobre Oruga 260 HP [6.53 h]; CARGADOR SOBRE LLANTAS DE 200-250 HP [3.26 h] |
| 1.07.644 |  | CONFORMACIÓN DE MATERIAL GRANULAR EN CORONA DE DIQUE A1-D-02 | 1.5d | 2024-03-25 | 2024-03-26 | 1.03.02 FS+0.5d | 73.97d | 73.99d | Camión Cisterna 4x2 400 HP Agua (5000 gal) [3.35 h]; CAPATAZ [6.7 h]; Motoniveladora 185 HP [6.7 h]; OPERARIO [6.7 h]; PEON [26.76 h]; Rodillo Vib. Liso Autopropulsado 135 HP 12 TM [6.7 h]; OFICIAL [6.7 h]; Excavadora Sobre Oruga 260 HP [6.7 h]; CARGADOR SOBRE LLANTAS DE 200-250 HP [3.35 h] |
| 1.07.642 |  | CONFORMACIÓN DE MATERIAL GRANULAR EN CORONA DE DIQUE A1-I-01 | 5.5d | 2024-05-27 | 2024-06-01 | 1.03.08 FS+0.5d, A1057 FF-0.4d | 1.96d | 0d | Camión Cisterna 4x2 400 HP Agua (5000 gal) [42.72 h]; CAPATAZ [85.43 h]; Motoniveladora 185 HP [85.43 h]; OPERARIO [85.43 h]; PEON [341.43 h]; Rodillo Vib. Liso Autopropulsado 135 HP 12 TM [85.43 h]; OFICIAL [85.43 h]; Excavadora Sobre Oruga 260 HP [85.43 h]; CARGADOR SOBRE LLANTAS DE 200-250 HP [42.72 h] |
| 1.07.646 |  | CONFORMACIÓN DE MATERIAL GRANULAR EN CORONA DE DIQUE A1-D-01 | 4.5d | 2024-06-17 | 2024-06-21 | 1.03.06 FS+0.5d, A1058 FF-0.4d | -0.02d | 0d | Camión Cisterna 4x2 400 HP Agua (5000 gal) [39.75 h]; CAPATAZ [79.51 h]; Motoniveladora 185 HP [79.51 h]; OPERARIO [79.51 h]; PEON [317.76 h]; Rodillo Vib. Liso Autopropulsado 135 HP 12 TM [79.51 h]; OFICIAL [79.51 h]; Excavadora Sobre Oruga 260 HP [79.51 h]; CARGADOR SOBRE LLANTAS DE 200-250 HP [39.75 h] |
|  | 4 | **OBRAS DE ARTE (REBOSES)** |  | 2024-01-20 | 2024-02-09 |  |  |  |  |
|  | 1 | **ESTRUCTURA DE REBOSE** |  | 2024-01-20 | 2024-02-09 |  |  |  |  |
|  | 1 | **MOVIMIENTO DE TIERRAS** |  | 2024-01-20 | 2024-02-09 |  |  |  |  |
| 1.08.01 |  | DESBROCE Y LIMPIEZA | 0.5d | 2024-01-20 | 2024-01-20 | 1.07.02 FS-0.1d | 94.22d | 0d | Camión Volquete (15 m3) [0.21 h]; Excavadora Sobre Oruga 260 HP [0.12 h]; OPERARIO [0.21 h]; PEON [1.31 h]; Tractor S/Orugas (D6T) - 180 HP [0.21 h] |
| 1.08.02 |  | EXCAVACIÓN ESTRUCTURAL BAJO AGUA | 2.5d | 2024-01-22 | 2024-01-24 | 1.08.01 FS+0.5d | 94.22d | 0d | CAPATAZ [2.12 h]; PEON [42.39 h]; Tractor S/Orugas (D6T) - 180 HP [21.19 h]; Excavadora Sobre Oruga 260 HP [21.19 h] |
| 1.08.03 |  | CAMA DE ARENA | 3.5d | 2024-01-25 | 2024-01-29 | 1.08.02 FS+0.5d | 94.22d | 0d | CAPATAZ [12.58 h]; PEON [100.64 h] |
| 1.08.04 |  | RELLENO ESTRUCTURAL PARA OBRAS DE ARTE CON MATERIAL DE PRÉSTAMO | 6.5d | 2024-02-01 | 2024-02-09 | 1.04.06 FS+0.5d | 94.22d | 0d | Camión Cisterna 4x2 400 HP Agua (5000 gal) [52.07 h]; CAPATAZ [5.21 h]; PEON [104.15 h]; Rodillo Vib. Liso Autopropulsado 135 HP 12 TM [52.07 h]; CUADRADOR/VIGÍA [52.07 h]; CARGADOR SOBRE LLANTAS DE 200-250 HP [26.04 h] |

| ID | WBS | Activity | Duration | Start | Finish | Predecessors | Total float | Free float | Resources |
| --- | --- | --- | --- | --- | --- | --- | --- | --- | --- |
|  | 5 | **TRANSPORTE DE MATERIAL** |  | 2024-01-02 | 2024-06-18 |  |  |  |  |
| 1.08.07 |  | TRANSPORTE DE MATERIAL EXCEDENTE | 64.5d | 2024-01-02 | 2024-03-16 | 1.07.03 SS+3.9d | 82.07d | 82.09d | Camión Volquete (15 m3) [67689.2 h]; CAPATAZ [219.55 h]; CUADRADOR/VIGÍA [61432.1 h]; Excavadora Sobre Oruga 260 HP [2085.69 h] |
| 1.08.06 |  | TRANSPORTE DE ROCA | 118.5d | 2024-01-20 | 2024-06-10 | 1.07.410 SS-3.1d, 1.03.06 FF-9.4d | 12.01d | 12.03d | CAPATAZ [30.32 h]; CUADRADOR/VIGÍA [4671.96 h]; Excavadora Sobre Oruga 260 HP [316.66 h]; Camión Volquete Roquero (15 m3) [5621.95 h] |
| 1.08.05 |  | TRANSPORTE DE MATERIAL GRANULAR | 122.5d | 2024-01-24 | 2024-06-18 | 1.07.618 SS-4.4d, 1.07.646 FF-3.5d | 5.31d | 5.34d | CAPATAZ [86.92 h]; Excavadora Sobre Oruga 260 HP [825.74 h]; Camión Volquete (15 m3) [35129.8 h]; CUADRADOR/VIGÍA [32652.6 h] |
|  | 6 | **INTERFERENCIAS** |  | 2024-05-18 | 2024-06-21 |  |  |  |  |
|  | 1 | **CANAL A REPONER DE SECCIÓN RECTANGULAR** |  | 2024-05-18 | 2024-06-21 |  |  |  |  |
|  | 1 | **MOVIMIENTO DE TIERRAS** |  | 2024-05-18 | 2024-06-21 |  |  |  |  |
| 1.09.01 |  | DEMOLICION DE ESTRUCTURAS EXISTENTE | 3.5d | 2024-05-18 | 2024-05-22 | 1.07.642 FS-12.5d | 1.96d | 0d | CAPATAZ [5.87 h]; OPERARIO [117.23 h]; PEON [175.86 h]; Excavadora + Martillo hidraúlico [58.63 h] |
| 1.09.02 |  | EXCAVACIÓN EN TERRENO NATURAL CON EQUIPO | 1.5d | 2024-05-21 | 2024-05-22 | 1.09.01 FS-1.5d | 1.96d | 0d | CAPATAZ [1.18 h]; PEON [11.82 h]; Excavadora Sobre Oruga 260 HP [11.82 h]; Tractor S/Orugas (D6T) - 180 HP [11.82 h] |
| 1.09.04 |  | ELIMINACIÓN DE PRODUCTOS DE DEMOLICIÓN DE OBRAS DE CONCRETO | 2.5d | 2024-05-22 | 2024-05-24 | 1.09.02 SS+1.06d | 25.96d | 25.98d | CAPATAZ [1.99 h]; OPERARIO [19.79 h]; PEON [19.79 h]; Camión Volquete (15 m3) [19.79 h]; Excavadora Sobre Oruga 260 HP [19.79 h] |
| 1.09.03 |  | RELLENO ESTRUCTURAL PARA OBRAS DE ARTE CON MATERIAL DE PRÉSTAMO | 4.5d | 2024-06-17 | 2024-06-21 | 1.04.10 FS-3.5d | 1.96d | 1.98d | CAPATAZ [10.84 h]; CUADRADOR/VIGÍA [108.35 h]; PEON [216.71 h]; Rodillo Vib. Liso Autopropulsado 135 HP 12 TM [108.35 h]; Camión Cisterna 4x2 400 HP Agua (5000 gal) [108.35 h]; CARGADOR SOBRE LLANTAS DE 200-250 HP [54.18 h] |
|  | 2 | **CANAL A REPONER DE SECCIÓN TRAPEZOIDAL** |  | 2024-05-23 | 2024-06-13 |  |  |  |  |
|  | 1 | **MOVIMIENTO DE TIERRAS** |  | 2024-05-23 | 2024-06-13 |  |  |  |  |
| 1.09.05 |  | DEMOLICION DE ESTRUCTURAS EXISTENTE | 3.5d | 2024-05-23 | 2024-05-27 | 1.09.01 FS+0.5d | 8.96d | 0d | CAPATAZ [2.92 h]; OPERARIO [58.28 h]; PEON [87.43 h]; Excavadora + Martillo hidraúlico [29.15 h] |
| 1.09.06 |  | EXCAVACIÓN EN TERRENO NATURAL CON EQUIPO | 1.5d | 2024-05-28 | 2024-05-29 | 1.09.05 FS+0.5d | 8.96d | 0d | CAPATAZ [0.98 h]; PEON [9.75 h]; Excavadora Sobre Oruga 260 HP [9.75 h]; Tractor S/Orugas (D6T) - 180 HP [9.75 h] |
| 1.09.08 |  | ELIMINACIÓN DE PRODUCTOS DE DEMOLICIÓN DE OBRAS DE CONCRETO | 1.5d | 2024-05-30 | 2024-05-31 | 1.09.06 FS+0.5d | 20.02d | 20.04d | CAPATAZ [0.99 h]; OPERARIO [9.84 h]; PEON [9.84 h]; Excavadora Sobre Oruga 260 HP [9.84 h]; Camión Volquete (15 m3) [9.84 h] |
| 1.09.07 |  | RELLENO ESTRUCTURAL PARA OBRAS DE ARTE CON MATERIAL DE PRÉSTAMO | 0.53d | 2024-06-13 | 2024-06-13 | 1.04.14 FS+0.53d | 8.96d | 8.98d | CAPATAZ [0.01 h]; CUADRADOR/VIGÍA [0.1 h]; PEON [0.19 h]; Rodillo Vib. Liso Autopropulsado 135 HP 12 TM [0.1 h]; Camión Cisterna 4x2 400 HP Agua (5000 gal) [0.1 h]; CARGADOR SOBRE LLANTAS DE 200-250 HP [0.05 h] |
|  | 7 | **PROGRAMA DE CIERRE DE OBRA** |  | 2024-01-22 | 2024-06-24 |  |  |  |  |
| 01.10.01 |  | ACONDICIONAMIENTO DE DEPÓSITOS DE MATERIALES EXCEDENTES (DME) | 115.5d | 2024-01-22 | 2024-06-07 | 1.07.03 FS+0.5d | 13.97d | 13.99d | Camión Cisterna 4x2 400 HP Agua (5000 gal) [706.08 h]; CAPATAZ [290.74 h]; OPERARIO [2782.79 h]; Tractor S/Orugas (D6T) - 180 HP [2782.79 h] |
| 01.10.02 |  | RESTAURACIÓN DE ÁREAS DE INSTALACIONES PROVISIONALES | 6.5d | 2024-06-15 | 2024-06-22 | 1.07.646 FS-5.5d | -0.02d | 0d | CAPATAZ [2.7 h]; PEON [21.3 h]; Camión Cisterna 4x2 400 HP Agua (5000 gal) [5.3 h]; Rodillo Vib. Liso Autopropulsado 135 HP 12 TM [5.3 h] |
| 01.10.03 |  | DESMOVILIZACIÓN | 6.5d | 2024-06-17 | 2024-06-24 | 01.10.02 FS-5.5d, 01.02.02 FF, 01.10.01 FF, 1.01.03 FF, 1.04.02 FF, 1.04.11 FF, 1.04.15 FF, 1.04.22 FF, 1.06.01 FF, 1.07.640 FF, 1.07.644 FF, 1.07.648 FF, 1.08.05 FF, 1.08.06 FF, 1.08.07 FF, 1.09.03 FF, 1.09.04 FF, 1.09.07 FF, 1.09.08 FF | -0.02d | 0.04d |  |
